# Proyecto de Ejemplo 1

Schedule from MS Project, 2024-10-01 to 2026-04-14, 6 hours a day.

## Calendars

- Estándar: Mon-Fri 09:00-13:00, 15:00-19:00; Sat-Sun off.
- Calendario L-Mi-V: Mon 08:00-12:00, 13:00-15:00; Tue off; Wed 08:00-12:00, 13:00-15:00; Thu off; Fri 08:00-12:00, 13:00-15:00; Sat-Sun off. Exceptions (off unless hours are given): 2025-01-01 (Año Nuevo), 2025-01-06 (Dia de Reyes), 2025-01-21 (Virgen De La Altagracia), 2025-02-27 (Independencia Nacional), 2025-04-17 (Jueves Santos), 2025-04-18 (Viernes santos), 2025-05-01 (Dia Del Trabajador), 2025-06-19 (Corpus Christi), 2025-09-24 (Dia de La Mercedes), 2025-11-10 (Dia de La Constitucion), 2025-12-24 (Noche Buena), 2025-12-25 (Navidad), 2025-12-31 (Fin de Año), 2026-01-01 (Año Nuevo), 2026-01-06 (Dia de Reyes), 2026-01-21 (Dia de La Altagracia), 2026-01-26 (Juan Pablo Duarte), 2026-02-27 (Independencia), 2026-04-02 (Jueves Santos), 2026-04-03 (Viernes Santos).
- Calendario Ma y J: Mon off; Tue 08:00-12:00, 13:00-15:00; Wed off; Thu 08:00-12:00, 13:00-15:00; Fri-Sun off. Exceptions (off unless hours are given): 2025-01-01 (Año Nuevo), 2025-01-06 (Dia de Reyes), 2025-01-21 (Virgen De La Altagracia), 2025-02-27 (Independencia Nacional), 2025-04-17 (Jueves Santos), 2025-04-18 (Viernes Santos), 2025-05-01 (Dia Del Trabajador), 2025-06-19 (Corpus Christi), 2025-08-16 (Dia de la Restauracion), 2025-09-24 (Dia de Las Mercedes), 2025-11-10 (Dia de la Constitucion), 2025-12-24 (Noche Buena), 2025-12-25 (Navidad), 2025-12-31 (Fin de Año), 2026-01-01 (Año Nuevo), 2026-01-06 (Dia de Reyes), 2026-01-21 (Dia de La Altagracia), 2026-01-26 (Dia de Duarte), 2026-02-27 (Independencia), 2026-04-02 (Jueves Santos), 2026-04-03 (Viernes Santos).

## Resources

| Resource |
| --- |
| Hoyero 1 |
| Hoyero 2 |
| Hoyero 3 |
| Hoyero 4 |
| Hoyero 5 |
| Hoyero 6 |
| Hoyero 7 |
| Hoyero 8 |
| Hoyero 9 |
| Hoyero 10 |
| Grúa 1 |
| Grúa 2 |
| Grúa 3 |
| Grúa 4 |
| Grúa 5 |
| Grúa 6 |
| Grúa 7 |
| Grúa 8 |
| Grúa 9 |
| Grúa 10 |
| Canasto 1 |
| Canasto 2 |
| Canasto 3 |
| Canasto 4 |
| Canasto 5 |
| Canasto 6 |
| Canasto 7 |
| Canasto 8 |
| Canasto 9 |
| Canasto 10 |
| Brigada de Normalización 1 |
| Brigada de Normalización 2 |
| Brigada de Normalización 3 |
| Brigada de Normalización 4 |
| Brigada de Normalización 5 |
| Brigada de Normalización 6 |
| Brigada de Normalización 7 |
| Brigada de Normalización 8 |
| Brigada de Normalización 9 |
| Brigada de Normalización 10 |
| Supervisor 1 |
| Supervisor 2 |
| Supervisor 3 |
| Supervisor 4 |
| Supervisor 5 |
| Supervisor 6 |
| Supervisor 7 |
| Supervisor 8 |
| Supervisor 9 |
| Supervisor 10 |
| Capataz 1 |
| Capataz 2 |
| Capataz 3 |
| Capataz 4 |
| Capataz 5 |
| Capataz 6 |
| Capataz 7 |
| Capataz 8 |
| Capataz 9 |
| Capataz 10 |
| Brigada de Poda 1 |
| Brigada de Poda 2 |
| Brigada de Poda 3 |
| Brigada de Poda 4 |
| Brigada de Poda 5 |
| Brigada de Poda 6 |
| Brigada de Poda 7 |
| Brigada de Poda 8 |
| Brigada de Poda 9 |
| Brigada de Poda 10 |
| Brigada Ligera 1 |
| Brigada Ligera 2 |
| Brigada Ligera 3 |
| Brigada Ligera 4 |
| Brigada Ligera 5 |
| Brigada Ligera 6 |
| Brigada Ligera 7 |
| Brigada Ligera 8 |
| Brigada Ligera 9 |
| Brigada Ligera 10 |
| Hoyero 1 A |
| Hoyero 2 B |
| Hoyero 3 C |
| Hoyero 4 D |
| Hoyero 5 E |
| Hoyero 6 F |
| Hoyero 7 G |
| Hoyero 8 H |
| Hoyero 9 I |
| Hoyero 10 J |
| Grúa 1 A |
| Grúa 2 B |
| Grúa 3 C |
| Grúa 4 D |
| Grúa 5 E |
| Grúa 6 F |
| Grúa 7 G |
| Grúa 8 H |
| Grúa 9 I |
| Grúa 10 J |
| Canasto 1 A |
| Canasto 2 B |
| Canasto 3 C |
| Canasto 4 D |
| Canasto 5 E |
| Canasto 6 F |
| Canasto 7 G |
| Canasto 8 H |
| Canasto 9 I |
| Canasto 10 J |
| Brigada de Normalización 1 A |
| Brigada de Normalización 2 B |
| Brigada de Normalización 3 C |
| Brigada de Normalización 4 D |
| Brigada de Normalización 5 E |
| Brigada de Normalización 6 F |
| Brigada de Normalización 7 G |
| Brigada de Normalización 8 H |
| Brigada de Normalización 9 I |
| Brigada de Normalización 10 J |
| Supervisor 1 A |
| Supervisor 2 B |
| Supervisor 3 C |
| Supervisor 4 D |
| Supervisor 5 E |
| Supervisor 6 F |
| Supervisor 7 G |
| Supervisor 8 H |
| Supervisor 9 I |
| Supervisor 10 J |
| Capataz 1 A |
| Capataz 2 B |
| Capataz 3 C |
| Capataz 4 D |
| Capataz 5 E |
| Capataz 6 F |
| Capataz 7 G |
| Capataz 8 H |
| Capataz 9 I |
| Capataz 10 J |
| Brigada de Poda 1 A |
| Brigada de Poda 2 B |
| Brigada de Poda 3 C |
| Brigada de Poda 4 D |
| Brigada de Poda 5 E |
| Brigada de Poda 6 F |
| Brigada de Poda 7 G |
| Brigada de Poda 8 H |
| Brigada de Poda 9 I |
| Brigada de Poda 10 J |
| Brigada Ligera 1 A |
| Brigada Ligera 2 B |
| Brigada Ligera 3 C |
| Brigada Ligera 4 D |
| Brigada Ligera 5 E |
| Brigada Ligera 6 F |
| Brigada Ligera 7 G |
| Brigada Ligera 8 H |
| Brigada Ligera 9 I |
| Brigada Ligera 10 J |
| Hoyero 11 |
| Hoyero 12 |
| Hoyero 13 |
| Hoyero 14 |
| Hoyero 15 |
| Hoyero 11 K |
| Hoyero 12 L |
| Hoyero 13 M |
| Hoyero 14 N |
| Hoyero 15 Ñ |
| Canasto 11 |
| Canasto 11 O |
| 6 actividades nuevas |
| 1 chat con mensajes nuevos |
| Canasto 12 P |
| Canasto 12 |

## Schedule

| ID | WBS | Task | Duration | Start | Finish | Predecessors | Total slack | Free slack | Constraint | Calendar | Resources | Work | Días Calendario | Cantidad |
| --- | --- | --- | --- | --- | --- | --- | --- | --- | --- | --- | --- | --- | --- | --- |
| 1 | 1 | **Proyecto LOTE-1 TAVERA, REPARADERO Y BONAGUA** | 534d | 2024-10-01 | 2026-04-14 |  | 0d |  |  | Estándar |  | 20778h | 561días |  |
| 2 | 1.1 | **Preparativos previos Obras** | 44d | 2024-10-01 | 2024-11-14 |  | 2.67d |  |  | Estándar |  |  | 45días |  |
| 3 | 1.1.1 | Reuniones con Contratista | 5d | 2024-10-01 | 2024-10-04 |  | 2.67d | 0d | start no earlier than 2024-10-01 | Estándar |  |  | 4días |  |
| 4 | 1.1.2 | Revisiones adicionales de Ingenieria-Replanteo | 30d | 2024-10-07 | 2024-11-06 | 3FS+1d | 2.67d | 0d |  | Estándar |  |  | 31días |  |
| 5 | 1.1.3 | Firma Minuta | 7d | 2024-11-07 | 2024-11-14 | 4FS+1d | 2.67d | 0d |  | Estándar |  |  | 8días |  |
| 6 | 1.1.4 | Obtension Recursos Contratista | 30d | 2024-10-07 | 2024-11-06 |  | 498.67d |  | start no earlier than 2024-10-07 | Estándar |  |  | 31días |  |
| 7 | 1.1.5 | Gestion de Materiales y Revision contra Fichas Tecnicas | 21d | 2024-10-07 | 2024-10-29 | 3FS+1d | 507d |  |  | Estándar |  |  | 23días |  |
| 8 | 1.2 | **Suministro Materiales** | 119d | 2024-10-17 | 2025-02-19 |  | 399d |  |  | Estándar |  |  | 126días |  |
| 9 | 1.2.1 | Suministro Postes | 90d | 2024-10-17 | 2025-01-20 | 4SS+10d | 399d | 0d |  | Estándar |  |  | 96días |  |
| 10 | 1.2.2 | Suministro Armados | 90d | 2024-10-31 | 2025-02-03 | 9SS+14d | 399d | 0d |  | Estándar |  |  | 96días |  |
| 11 | 1.2.3 | Suministro Tendido (Cables) | 90d | 2024-11-15 | 2025-02-19 | 10SS+15d | 399d | 0d |  | Estándar |  |  | 97días |  |
| 12 | 1.2.4 | Suministro Transformadores | 90d | 2024-11-15 | 2025-02-19 | 11SS | 399d |  |  | Estándar |  |  | 97días |  |
| 13 | 1.2.5 | Suministro Equipos Proteccion | 90d | 2024-11-15 | 2025-02-19 | 11SS | 399d |  |  | Estándar |  |  | 97días |  |
| 14 | 1.2.6 | Suminiostro Alumbrado Publico | 90d | 2024-11-15 | 2025-02-19 | 11SS | 399d |  |  | Estándar |  |  | 97días |  |
| 15 | 1.2.7 | Suministro Acometida y medidores | 90d | 2024-11-15 | 2025-02-19 | 11SS | 399d |  |  | Estándar |  |  | 97días |  |
| 16 | 1.3 | **Ejecucion de Obras** | 209d | 2024-11-18 | 2026-04-14 |  | 0d |  |  |  |  | 20778h | 513días |  |
| 17 | 1.3.1 | **Poligono 1** | 99d | 2024-11-18 | 2025-07-11 |  | 63d |  |  |  |  | 5526h | 236días |  |
| 18 | 1.3.1.1 | Excavaciones | 17d | 2024-11-18 | 2024-12-25 | 5FS+1d | 63d | 0d |  |  | Hoyero 1; Hoyero 2; Hoyero 3; Hoyero 4; Hoyero 5; Hoyero 6; Hoyero 7; Hoyero 8; Hoyero 9; Hoyero 10; Hoyero 11; Hoyero 12; Hoyero 13; Hoyero 14; Hoyero 15 | 1530h | 38días | 1,027 |
| 19 | 1.3.1.2 | Izado de postes | 18d | 2024-11-18 | 2024-12-27 | 18SS | 63d | 0d |  |  | Grúa 1; Grúa 2; Grúa 3; Grúa 4 | 432h | 40días | 509 |
| 20 | 1.3.1.3 | Cimentaciones | 2d | 2025-01-10 | 2025-01-13 | 19FF | 186d |  |  |  | Brigada Ligera 1; Brigada Ligera 2 | 24h | 4días | 24 |
| 21 | 1.3.1.4 | Retenidas | 13d | 2024-11-18 | 2024-12-16 | 19SS | 196d |  |  |  | Brigada Ligera 3; Canasto 2; Brigada Ligera 4; Canasto 1; Brigada Ligera 5; Canasto 3; Brigada Ligera 6; Canasto 4 | 624h | 29días | 518 |
| 22 | 1.3.1.5 | Armados MT y BT | 18d | 2024-11-20 | 2024-12-30 | 19SS+1d | 63d | 0d |  |  | Canasto 5; Canasto 6; Canasto 7; Canasto 8; Canasto 9; Canasto 10 | 648h | 41días | 883 |
| 23 | 1.3.1.6 | Tendido de Conductor MT y BT | 23d | 2024-12-20 | 2025-02-14 | 22SS+13d | 63d | 0d |  |  | Canasto 1; Canasto 2; Canasto 3; Canasto 4; Canasto 11 | 690h | 57días | 39,382 |
| 24 | 1.3.1.7 | Puesta a Tierra | 6d | 2025-01-22 | 2025-02-03 | 23SS+12d | 165d | 0d |  |  | Canasto 5; Canasto 6; Canasto 7; Canasto 8; Canasto 9 | 180h | 13días | 304 |
| 25 | 1.3.1.8 | Conexiones y Jumper | 5d | 2025-02-17 | 2025-02-26 | 23 | 63d | 0d |  |  | Canasto 1; Canasto 2; Canasto 3; Canasto 4; Canasto 12 | 150h | 10días | 268 |
| 26 | 1.3.1.9 | Transformadores | 4d | 2025-03-10 | 2025-03-17 | 25SS+9d | 63d | 0d |  |  | Canasto 2; Grúa 1; Grúa 2; Canasto 1; Grúa 3; Canasto 3; Canasto 12; Grúa 4 | 192h | 8días | 58 |
| 27 | 1.3.1.10 | Alumbrado Público | 7d | 2025-03-21 | 2025-04-04 | 26FS+1d | 151d |  |  |  | Canasto 4; Canasto 5; Canasto 1; Canasto 2; Canasto 3 | 210h | 15días | 536 |
| 28 | 1.3.1.11 | Etiquetas CT | 1d | 2025-03-19 | 2025-03-19 | 26SS+4d | 63d | 0d |  |  | Canasto 9; Canasto 4; Canasto 5; Canasto 12 | 24h | 1días | 60 |
| 29 | 1.3.1.12 | Totalizadores | 7d | 2025-03-24 | 2025-04-07 | 28SS+2d | 150d |  |  |  | Canasto 6; Canasto 10; Canasto 11 | 126h | 15días | 60 |
| 30 | 1.3.1.13 | Acometida | 26d | 2025-03-28 | 2025-05-28 | 28FS+3d | 110d | 0d |  |  | Brigada de Normalización 1; Brigada de Normalización 2 | 312h | 62días | 1,050 |
| 31 | 1.3.1.14 | Remoción | 16d | 2025-06-06 | 2025-07-11 | 30FS+3d | 110d |  |  |  | Canasto 1; Grúa 1; Grúa 2; Canasto 6 | 384h | 36días | 1,600 |

Notes:
- 19: No se le asigna canasto, pero requiere uno para apertura y cierre de seccionador
- 23: Con una grua es suficiente para darle apoyo a los canastos.

| ID | WBS | Task | Duration | Start | Finish | Predecessors | Total slack | Free slack | Calendar | Resources | Work | Días Calendario | Cantidad |
| --- | --- | --- | --- | --- | --- | --- | --- | --- | --- | --- | --- | --- | --- |
| 33 | 1.3.2 | **Poligono 2** | 123d | 2024-11-21 | 2025-09-11 |  | 0d |  |  |  | 5160h | 295días |  |
| 34 | 1.3.2.1 | Excavaciones | 16d | 2024-11-21 | 2025-01-14 | 5FS+1d | 0d |  | Calendario Ma y J | Hoyero 1 A; Hoyero 2 B; Hoyero 3 C; Hoyero 4 D; Hoyero 5 E; Hoyero 6 F; Hoyero 7 G; Hoyero 8 H; Hoyero 9 I; Hoyero 10 J; Hoyero 11 K; Hoyero 12 L; Hoyero 13 M; Hoyero 14 N; Hoyero 15 Ñ | 1440h | 55días | 946 |
| 35 | 1.3.2.2 | Izado de postes | 16d | 2024-11-21 | 2025-01-14 | 34SS | 0d |  | Calendario Ma y J | Grúa 1 A; Grúa 2 B; Grúa 3 C; Grúa 4 D | 384h | 55días | 454 |
| 36 | 1.3.2.3 | Cimentaciones | 4d | 2024-12-31 | 2025-01-09 | 35SS+11d | 122d |  | Calendario Ma y J | Brigada Ligera 1 A; Brigada Ligera 2 B; Brigada Ligera 3 C | 72h | 10días | 55 |
| 37 | 1.3.2.4 | Retenidas | 10d | 2024-12-03 | 2025-01-02 | 35SS+3d | 124d |  | Calendario Ma y J | Brigada Ligera 4 D; Canasto 1 A; Canasto 2 B; Brigada Ligera 5 E; Canasto 3 C; Canasto 4 D; Canasto 5 E; Brigada Ligera 6 F; Brigada Ligera 7 G; Brigada Ligera 8 H | 600h | 31días | 492 |
| 38 | 1.3.2.5 | Armados MT y BT | 15d | 2024-12-03 | 2025-01-23 | 35SS+3d | 0d |  | Calendario Ma y J | Canasto 6 F; Canasto 7 G; Canasto 8 H; Canasto 9 I; Canasto 10 J; Canasto 11 O; Canasto 12 P | 630h | 52días | 854 |
| 39 | 1.3.2.6 | Tendido de Conductor MT y BT | 19d | 2025-01-07 | 2025-03-18 | 38SS+10d | 0d |  | Calendario Ma y J | Canasto 1 A; Canasto 2 B; Canasto 3 C; Canasto 4 D; Canasto 5 E | 570h | 71días | 33,039 |
| 40 | 1.3.2.7 | Puesta a Tierra | 7d | 2025-01-28 | 2025-02-18 | 38 | 106d | 0d | Calendario Ma y J | Canasto 9 I; Canasto 6 F; Canasto 7 G; Canasto 8 H | 168h | 22días | 267 |
| 41 | 1.3.2.8 | Conexiones y Jumper | 9d | 2025-02-18 | 2025-03-20 | 39SS+11d | 92d | 0d | Calendario Ma y J | Canasto 10 J; Canasto 11 O; Canasto 12 P | 162h | 31días | 258 |
| 42 | 1.3.2.9 | Transformadores | 5d | 2025-03-20 | 2025-04-03 | 39 | 0d |  | Calendario Ma y J | Canasto 4 D; Grúa 1 A; Grúa 2 B; Grúa 3 C; Grúa 4 D; Canasto 1 A; Canasto 2 B; Canasto 3 C | 240h | 15días | 65 |
| 43 | 1.3.2.10 | Alumbrado Público | 8d | 2025-04-08 | 2025-05-08 | 42SS+5d | 0d |  | Calendario Ma y J | Canasto 1 A; Canasto 3 C; Canasto 2 B; Canasto 4 D | 192h | 31días | 468 |
| 44 | 1.3.2.11 | Etiquetas CT | 2d | 2025-04-10 | 2025-04-15 | 42SS+6d | 57d | 0d | Calendario Ma y J | Canasto 5 E; Canasto 6 F; Canasto 7 G | 36h | 6días | 68 |
| 45 | 1.3.2.12 | Totalizadores | 7d | 2025-04-22 | 2025-05-15 | 44SS+2d | 90d |  | Calendario Ma y J | Canasto 5 E; Canasto 6 F; Canasto 7 G | 126h | 24días | 68 |
| 46 | 1.3.2.13 | Acometida | 23d | 2025-05-06 | 2025-07-24 | 44FS+3d | 57d | 0d | Calendario Ma y J | Brigada de Normalización 1 A; Brigada de Normalización 2 B | 276h | 80días | 905 |
| 47 | 1.3.2.14 | Remoción | 11d | 2025-08-07 | 2025-09-11 | 46FS+3d | 57d |  | Calendario Ma y J | Canasto 1 A; Grúa 1 A; Canasto 12 P; Grúa 6 F | 264h | 36días | 1,100 |
| 49 | 1.3.3 | **Poligono 3** | 109d | 2024-12-30 | 2025-09-15 |  | 82d |  |  |  | 3162h | 260días |  |
| 50 | 1.3.3.1 | Excavaciones | 9d | 2024-12-30 | 2025-01-22 | 18FS+1d | 180d | 0d |  | Hoyero 3; Hoyero 4; Hoyero 5; Hoyero 6; Hoyero 7; Hoyero 8; Hoyero 9; Hoyero 10; Hoyero 11; Hoyero 12; Hoyero 13; Hoyero 14; Hoyero 15; Hoyero 1; Hoyero 2 | 810h | 24días | 526 |
| 51 | 1.3.3.2 | Izado de postes | 10d | 2024-12-30 | 2025-01-24 | 50SS | 180d | 0d |  | Grúa 3; Grúa 4; Grúa 1; Grúa 2 | 240h | 26días | 261 |
| 52 | 1.3.3.3 | Cimentaciones | 1d | 2025-01-24 | 2025-01-24 | 51FF | 181d |  |  | Brigada Ligera 1; Brigada Ligera 2 | 12h | 1días | 11 |
| 53 | 1.3.3.4 | Retenidas | 9d | 2025-01-08 | 2025-01-27 | 51SS+2d | 180d |  |  | Brigada Ligera 3; Brigada Ligera 4; Canasto 10; Brigada Ligera 5; Canasto 12 | 270h | 20días | 265 |
| 54 | 1.3.3.5 | Armados MT y BT | 12d | 2025-02-05 | 2025-03-03 | 24 | 165d |  |  | Canasto 6; Canasto 7; Canasto 8; Canasto 10; Canasto 5 | 360h | 27días | 497 |
| 55 | 1.3.3.6 | Tendido de Conductor MT y BT | 15d | 2025-03-21 | 2025-04-25 | 28 | 63d | 0d |  | Canasto 7; Canasto 8; Canasto 12; Canasto 9 | 360h | 36días | 20,820 |
| 56 | 1.3.3.7 | Puesta a Tierra | 3d | 2025-04-07 | 2025-04-11 | 55SS+7d | 148d |  |  | Canasto 1; Canasto 2; Canasto 3; Canasto 4 | 72h | 5días | 122 |
| 57 | 1.3.3.8 | Conexiones y Jumper | 3d | 2025-05-02 | 2025-05-07 | 55SS+17d | 63d | 0d |  | Canasto 5; Canasto 6; Canasto 7; Canasto 8 | 72h | 6días | 119 |
| 58 | 1.3.3.9 | Transformadores | 3d | 2025-05-09 | 2025-05-14 | 57SS+3d | 63d | 0d |  | Grúa 3; Canasto 3; Canasto 4; Canasto 5; Grúa 4; Grúa 5 | 108h | 6días | 30 |
| 59 | 1.3.3.10 | Alumbrado Público | 5d | 2025-05-16 | 2025-05-26 | 58 | 130d |  |  | Canasto 4; Canasto 5; Canasto 7; Canasto 6 | 120h | 11días | 264 |
| 60 | 1.3.3.11 | Etiquetas CT | 1d | 2025-05-16 | 2025-05-16 | 58 | 82d | 0d |  | Canasto 1; Canasto 2 | 12h | 1días | 30 |
| 61 | 1.3.3.12 | Totalizadores | 5d | 2025-05-19 | 2025-05-28 | 60SS+1d | 82d | 0d |  | Canasto 3; Canasto 8; Canasto 9 | 90h | 10días | 30 |
| 62 | 1.3.3.13 | Acometida | 33d | 2025-06-02 | 2025-08-15 | 61FS+1d | 82d | 0d |  | Brigada de Normalización 1; Brigada de Normalización 2 | 396h | 75días | 1,313 |
| 63 | 1.3.3.14 | Remoción | 10d | 2025-08-25 | 2025-09-15 | 62FS+3d | 82d |  |  | Grúa 2; Canasto 2; Canasto 1; Grúa 1 | 240h | 22días | 950 |

Notes:
- 35: No se le asigna canasto, pero requiere uno para apertura y cierre de seccionador
- 39: Con una grua es suficiente para darle apoyo a los canastos.
- 51: No se le asigna canasto, pero requiere uno para apertura y cierre de seccionador
- 55: Con una grua es suficiente para darle apoyo a los canastos.

| ID | WBS | Task | Duration | Start | Finish | Predecessors | Total slack | Free slack | Calendar | Resources | Work | Días Calendario | Cantidad |
| --- | --- | --- | --- | --- | --- | --- | --- | --- | --- | --- | --- | --- | --- |
| 65 | 1.3.4 | **Poligono 4** | 90d | 2025-01-16 | 2025-12-11 |  | 29d |  | Calendario Ma y J |  | 2814h | 330días |  |
| 66 | 1.3.4.1 | Excavaciones | 8d | 2025-01-16 | 2025-02-13 | 34 | 113d | 0d | Calendario Ma y J | Hoyero 1 A; Hoyero 2 B; Hoyero 3 C; Hoyero 4 D; Hoyero 5 E; Hoyero 6 F; Hoyero 7 G; Hoyero 8 H; Hoyero 9 I; Hoyero 10 J; Hoyero 11 K; Hoyero 12 L; Hoyero 13 M; Hoyero 14 N; Hoyero 15 Ñ | 720h | 29días | 457 |
| 67 | 1.3.4.2 | Izado de postes | 6d | 2025-01-16 | 2025-02-06 | 66SS | 115d | 0d | Calendario Ma y J | Grúa 1 A; Grúa 2 B; Grúa 3 C; Grúa 4 D; Grúa 5 E | 180h | 22días | 216 |
| 68 | 1.3.4.3 | Cimentaciones | 1d | 2025-02-06 | 2025-02-06 | 67FF | 115d |  | Calendario Ma y J | Brigada Ligera 1 A; Brigada Ligera 2 B; Brigada Ligera 3 C | 18h | 1días | 16 |
| 69 | 1.3.4.4 | Retenidas | 6d | 2025-02-20 | 2025-03-13 | 40 | 106d |  | Calendario Ma y J | Brigada Ligera 4 D; Brigada Ligera 5 E; Brigada Ligera 6 F; Brigada Ligera 7 G; Canasto 6 F; Canasto 7 G; Canasto 8 H; Canasto 9 I | 288h | 22días | 241 |
| 70 | 1.3.4.5 | Armados MT y BT | 12d | 2025-03-25 | 2025-05-08 | 41 | 92d |  | Calendario Ma y J | Canasto 10 J; Canasto 11 O; Canasto 12 P | 216h | 45días | 284 |
| 71 | 1.3.4.6 | Tendido de Conductor MT y BT | 13d | 2025-05-13 | 2025-06-26 | 43 | 0d |  | Calendario Ma y J | Canasto 1 A; Canasto 2 B; Canasto 3 C; Canasto 4 D | 312h | 45días | 18,042 |
| 72 | 1.3.4.7 | Puesta a Tierra | 4d | 2025-06-10 | 2025-06-24 | 71SS+8d | 80d |  | Calendario Ma y J | Canasto 5 E; Canasto 6 F; Canasto 7 G; Canasto 8 H | 96h | 15días | 165 |
| 73 | 1.3.4.8 | Conexiones y Jumper | 5d | 2025-07-03 | 2025-07-17 | 71SS+14d | 0d |  | Calendario Ma y J | Canasto 3 C; Canasto 4 D; Canasto 5 E; Canasto 6 F | 120h | 15días | 206 |
| 74 | 1.3.4.9 | Transformadores | 4d | 2025-07-10 | 2025-07-22 | 73SS+2d | 0d |  | Calendario Ma y J | Grúa 3 C; Grúa 4 D; Grúa 5 E; Canasto 9 I; Canasto 10 J; Canasto 11 O | 144h | 13días | 34 |
| 75 | 1.3.4.10 | Alumbrado Público | 4d | 2025-07-22 | 2025-07-31 | 73 | 69d |  | Calendario Ma y J | Canasto 3 C; Canasto 4 D; Canasto 5 E; Canasto 6 F | 96h | 10días | 240 |
| 76 | 1.3.4.11 | Etiquetas CT | 1d | 2025-07-24 | 2025-07-24 | 74 | 31d | 0d | Calendario Ma y J | Canasto 7 G; Canasto 8 H | 12h | 1días | 36 |
| 77 | 1.3.4.12 | Totalizadores | 3d | 2025-07-29 | 2025-08-05 | 76 | 31d | 0d | Calendario Ma y J | Canasto 7 G; Canasto 8 H; Canasto 9 I; Canasto 10 J | 72h | 8días | 36 |
| 78 | 1.3.4.13 | Acometida | 21d | 2025-08-12 | 2025-10-21 | 77FS+1d | 31d | 0d | Calendario Ma y J | Brigada de Normalización 1 A; Brigada de Normalización 2 B | 252h | 71días | 820 |
| 79 | 1.3.4.14 | Remoción | 12d | 2025-11-04 | 2025-12-11 | 78FS+3d | 31d |  | Calendario Ma y J | Canasto 1 A; Grúa 1 A; Grúa 2 B; Canasto 6 F | 288h | 38días | 1,200 |
| 81 | 1.3.5 | **Poligono 5** | 72d | 2025-05-16 | 2025-10-31 |  | 63d |  |  |  | 2034h | 169días |  |
| 82 | 1.3.5.1 | Excavaciones | 5d | 2025-05-16 | 2025-05-26 | 58 | 63d | 0d |  | Hoyero 4; Hoyero 5; Hoyero 6; Hoyero 7; Hoyero 8; Hoyero 9; Hoyero 10; Hoyero 11; Hoyero 12; Hoyero 13; Hoyero 14; Hoyero 15; Hoyero 1; Hoyero 2; Hoyero 3 | 450h | 11días | 320 |
| 83 | 1.3.5.2 | Izado de postes | 6d | 2025-05-16 | 2025-05-28 | 82SS | 63d | 0d |  | Grúa 4; Grúa 2; Grúa 5; Grúa 3 | 144h | 13días | 158 |
| 84 | 1.3.5.3 | Cimentaciones | 1d | 2025-05-28 | 2025-05-28 | 83FF | 129d |  |  | Brigada Ligera 2; Brigada Ligera 1 | 12h | 1días |  |
| 85 | 1.3.5.4 | Retenidas | 5d | 2025-05-21 | 2025-05-30 | 83SS+2d | 128d |  |  | Brigada Ligera 4; Canasto 10; Brigada Ligera 5; Canasto 11; Brigada Ligera 3 | 150h | 10días | 162 |
| 86 | 1.3.5.5 | Armados MT y BT | 10d | 2025-05-30 | 2025-06-20 | 83SS+6d | 63d | 0d |  | Canasto 3; Canasto 4; Canasto 5; Canasto 2 | 240h | 22días | 309 |
| 87 | 1.3.5.6 | Tendido de Conductor MT y BT | 9d | 2025-06-23 | 2025-07-11 | 86 | 63d | 0d |  | Canasto 3; Canasto 4; Canasto 5; Canasto 2 | 216h | 19días | 12,030 |
| 88 | 1.3.5.7 | Puesta a Tierra | 3d | 2025-07-14 | 2025-07-18 | 87 | 63d | 0d |  | Canasto 3; Canasto 4; Canasto 5; Canasto 2 | 72h | 5días | 119 |
| 89 | 1.3.5.8 | Conexiones y Jumper | 2d | 2025-07-21 | 2025-07-23 | 88 | 63d | 0d |  | Canasto 3; Canasto 4; Canasto 5; Canasto 2 | 48h | 3días | 87 |
| 90 | 1.3.5.9 | Transformadores | 3d | 2025-07-25 | 2025-07-30 | 89 | 63d | 0d |  | Canasto 4; Canasto 5; Grúa 3; Grúa 4; Grúa 5; Canasto 3 | 108h | 6días | 25 |
| 91 | 1.3.5.10 | Alumbrado Público | 3d | 2025-08-01 | 2025-08-06 | 90 | 63d | 0d |  | Canasto 4; Canasto 5; Canasto 6; Canasto 3 | 72h | 6días | 165 |
| 92 | 1.3.5.11 | Etiquetas CT | 1d | 2025-08-08 | 2025-08-08 | 91 | 63d | 0d |  | Canasto 4; Canasto 3 | 12h | 1días | 31 |
| 93 | 1.3.5.12 | Totalizadores | 3d | 2025-08-11 | 2025-08-15 | 92 | 63d | 0d |  | Canasto 4; Canasto 5; Canasto 3 | 54h | 5días | 31 |
| 94 | 1.3.5.13 | Acometida | 18d | 2025-08-20 | 2025-10-01 | 93FS+1d | 63d | 0d |  | Brigada de Normalización 2; Brigada de Normalización 1 | 216h | 43días | 715 |
| 95 | 1.3.5.14 | Remoción | 10d | 2025-10-10 | 2025-10-31 | 94FS+3d | 63d |  |  | Grúa 1; Canasto 2; Grúa 2; Canasto 1 | 240h | 22días | 1,000 |

Notes:
- 67: No se le asigna canasto, pero requiere uno para apertura y cierre de seccionador
- 71: Con una grua es suficiente para darle apoyo a los canastos.
- 83: No se le asigna canasto, pero requiere uno para apertura y cierre de seccionador
- 87: Con una grua es suficiente para darle apoyo a los canastos.

| ID | WBS | Task | Duration | Start | Finish | Predecessors | Total slack | Calendar | Resources | Work | Días Calendario | Cantidad |
| --- | --- | --- | --- | --- | --- | --- | --- | --- | --- | --- | --- | --- |
| 97 | 1.3.6 | **Poligono 6** | 72d | 2025-07-24 | 2026-04-14 |  | 0d | Calendario Ma y J |  | 2082h | 265días |  |
| 98 | 1.3.6.1 | Excavaciones | 5d | 2025-07-24 | 2025-08-07 | 74 | 0d | Calendario Ma y J | Hoyero 3 C; Hoyero 4 D; Hoyero 5 E; Hoyero 6 F; Hoyero 7 G; Hoyero 8 H; Hoyero 9 I; Hoyero 10 J; Hoyero 11 K; Hoyero 12 L; Hoyero 13 M; Hoyero 14 N; Hoyero 15 Ñ; Hoyero 1 A; Hoyero 2 B | 450h | 15días | 296 |
| 99 | 1.3.6.2 | Izado de postes | 6d | 2025-07-24 | 2025-08-12 | 98SS | 0d | Calendario Ma y J | Grúa 4 D; Grúa 5 E; Grúa 2 B; Grúa 3 C | 144h | 20días | 162 |
| 100 | 1.3.6.3 | Cimentaciones | 1d | 2025-08-12 | 2025-08-12 | 99FF | 66d | Calendario Ma y J | Brigada Ligera 1 A | 6h | 1días |  |
| 101 | 1.3.6.4 | Retenidas | 3d | 2025-08-14 | 2025-08-21 | 99 | 0d | Calendario Ma y J | Canasto 3 C; Brigada Ligera 1 A; Brigada Ligera 2 B; Brigada Ligera 3 C; Brigada Ligera 4 D; Canasto 2 B | 108h | 8días | 134 |
| 102 | 1.3.6.5 | Armados MT y BT | 8d | 2025-08-26 | 2025-09-18 | 101 | 0d | Calendario Ma y J | Canasto 4 D; Canasto 5 E; Canasto 6 F; Canasto 2 B; Canasto 3 C | 240h | 24días | 330 |
| 103 | 1.3.6.6 | Tendido de Conductor MT y BT | 10d | 2025-09-23 | 2025-10-23 | 102 | 0d | Calendario Ma y J | Canasto 4 D; Canasto 5 E; Canasto 2 B; Canasto 3 C | 240h | 31días | 13,805 |
| 104 | 1.3.6.7 | Puesta a Tierra | 2d | 2025-10-28 | 2025-10-30 | 103 | 0d | Calendario Ma y J | Canasto 3 C; Canasto 4 D; Canasto 5 E; Canasto 2 B | 48h | 3días | 96 |
| 105 | 1.3.6.8 | Conexiones y Jumper | 2d | 2025-11-04 | 2025-11-06 | 104 | 0d | Calendario Ma y J | Canasto 2 B; Canasto 3 C; Canasto 4 D; Canasto 5 E | 48h | 3días | 84 |
| 106 | 1.3.6.9 | Transformadores | 3d | 2025-11-11 | 2025-11-18 | 105 | 0d | Calendario Ma y J | Grúa 3 C; Grúa 4 D; Canasto 2 B; Canasto 3 C; Canasto 4 D; Grúa 5 E | 108h | 8días | 24 |
| 107 | 1.3.6.10 | Alumbrado Público | 3d | 2025-11-20 | 2025-11-27 | 106 | 0d | Calendario Ma y J | Canasto 2 B; Canasto 3 C; Canasto 4 D; Canasto 5 E | 72h | 8días | 174 |
| 108 | 1.3.6.11 | Etiquetas CT | 1d | 2025-12-02 | 2025-12-02 | 107 | 0d | Calendario Ma y J | Canasto 3 C; Canasto 2 B | 12h | 1días | 29 |
| 109 | 1.3.6.12 | Totalizadores | 3d | 2025-12-04 | 2025-12-11 | 108 | 0d | Calendario Ma y J | Canasto 3 C; Canasto 4 D; Canasto 2 B | 54h | 8días | 29 |
| 110 | 1.3.6.13 | Acometida | 8d | 2025-12-18 | 2026-01-22 | 109FS+1d | 0d | Calendario Ma y J | Brigada de Normalización 1 A; Brigada de Normalización 2 B | 96h | 36días | 325 |
| 111 | 1.3.6.14 | Remoción | 19d | 2026-02-05 | 2026-04-14 | 110FS+3d | 0d | Calendario Ma y J | Grúa 2 B; Canasto 1 A; Grúa 1 A; Canasto 2 B | 456h | 69días | 950 |

Notes:
- 99: No se le asigna canasto, pero requiere uno para apertura y cierre de seccionador
- 103: Con una grua es suficiente para darle apoyo a los canastos.
